# Časový postup prací - Optimalizace traťového úseku Praha Hostivař - Praha Hlavní nádraží I část - ZKRÁCENÁ

Schedule from MS Project, 2015-11-02 to 2017-05-31, status date 2012-12-01.
SUDOP PRAHA a.s.

## Calendars

- Standardní: Mon-Sun 08:00-12:00, 13:00-17:00. Exceptions (off unless hours are given): 2016-01-01 to 2020-01-01 (Nový rok, recurring), 2016-12-24 to 2020-12-24 (Štědrý den, recurring).

## Resources

| Resource |
| --- |
| PKP 25 |

## Schedule

| ID | WBS | Task | Duration | Start | Finish | Predecessors | Total slack | Free slack | Constraint | Text1 |
| --- | --- | --- | --- | --- | --- | --- | --- | --- | --- | --- |
| 1 | 1 | **Modernizace ŽST Česká Lípa** | 574d | 2015-11-02 | 2017-05-31 |  | 0d |  |  |  |
| 2 | 1.1 | **Přípravné práce probíhající přes zimu** | 29d | 2015-11-02 | 2015-11-30 |  | 0d |  |  |  |
| 3 | 1.1.1 | Vytyčení ploch ZS, zřízení zázemí pro zhotovitele | 29d | 2015-11-02 | 2015-11-30 |  | 0d |  |  |  |
| 4 | 1.2 | **Technologická přestávka** | 121d | 2015-12-01 | 2016-03-31 |  |  |  |  |  |
| 5 | 1.2.1 | Přeložky a ochrana stávajících inž. sítí | 90d | 2015-12-01 | 2016-02-29 | 2 | 31d |  |  |  |
| 6 | 1.3 | **Práce probíhající v technologické přestávce, v případě venkovních prací při klimaticky přiznívých podmínkách** | 270d | 2015-12-01 | 2016-08-27 |  | 0d |  |  |  |
| 7 | 1.3.1 | Objednání materiálu, stavebních prvků a technologií (pro zab. zař., trafostanici, rozvodny apod.) | 180d | 2015-12-01 | 2016-05-29 | 3 | 0d |  |  |  |
| 8 | 1.3.2 | **Úpravy ve VB** | 120d | 2015-12-01 | 2016-03-30 |  | 60d |  |  | SO 14-40-02 |
| 9 | 1.3.2.1 | Místnost pro dispečery | 60d | 2015-12-01 | 2016-01-30 | 3 | 120d |  |  |  |
| 10 | 1.3.2.2 | Místnost pro rozvodnu | 120d | 2015-12-01 | 2016-03-30 | 3 | 60d |  | start no earlier than 2015-10-01 |  |
| 11 | 1.3.2.3 | Místnost pro techn. zab.zař. | 120d | 2015-12-01 | 2016-03-30 | 3 | 60d |  | start no earlier than 2015-10-01 |  |
| 12 | 1.3.3 | Objednání , výroba a dodání výhybek | 152d | 2015-12-01 | 2016-05-01 | 3 | 423d |  |  |  |
| 13 | 1.3.4 | Pokládka kabelových tras | 182d | 2015-12-01 | 2016-05-31 | 3 | 393d |  |  |  |
| 14 | 1.3.5 | Rekonstrukce stávající trafostanice včetně nových rozvodů a zařízení | 90d | 2015-12-01 | 2016-02-29 | 3 | 485d |  |  | SO 14-40-03 |
| 15 | 1.3.6 | Podchod pod staniční budovou v místě snesených kolejí č. 2a,6b + 30 dní časová rezerva na špatné klimatické podmínky | 120d | 2015-12-01 | 2016-03-30 | 3 | 305d | 0d |  | SO 14-20-01 |
| 16 | 1.3.7 | Budova pro odbavení cestujících | 150d | 2016-03-31 | 2016-08-27 | 15 | 305d |  |  | SO 14-40-01 |
| 17 | 1.3.8 | Montáž def. zab. zař. včetně odzkoušení | 90d | 2016-05-30 | 2016-08-27 | 7, 8 | 0d |  |  | PS 14/02/04 - 01-01 |
| 18 | 1.3.9 | Rekonstrukce VB v Žízníkově včetně montáže technologie | 120d | 2015-12-01 | 2016-03-30 | 3 | 455d |  |  | SO 02-40-01 |
| 19 | 1.4 | **Přípravné práce 2016** | 88d | 2016-04-01 | 2016-06-27 |  | 2d | 0d |  |  |
| 20 | 1.4.1 | **I. etapa** | 31d | 2016-04-01 | 2016-05-01 |  | 2d | 0d |  |  |
| 21 | 1.4.1.1 | Snesení kolejí č. 4a,6a část koleje č. 9,15,17,19 | 14d | 2016-04-01 | 2016-04-14 | 4 | 2d | 0d |  | SO 14-10/11-01, SO 14-14-01 |
| 22 | 1.4.1.2 | Realizace protlaků napříč kolejištěm | 14d | 2016-04-08 | 2016-04-21 | 21SS+7d | 2d | 0d |  |  |
| 23 | 1.4.1.3 | Snesení lávky nad kolejemi č.9-19 | 1d | 2016-04-14 | 2016-04-14 | 21FF | 9d | 7d |  | SO 14-26-51 |
| 24 | 1.4.1.4 | Nové koleje č. 9 (st.č.15) a 11(st.č.17) | 10d | 2016-04-22 | 2016-05-01 | 21, 23, 22 | 2d |  |  | SO 14-10/11-01 |

| ID | WBS | Task | Duration | Start | Finish | Predecessors | Total slack | Free slack | Text1 |
| --- | --- | --- | --- | --- | --- | --- | --- | --- | --- |
| 25 | 1.4.2 | **II. etapa** | 57d | 2016-05-02 | 2016-06-27 |  | 2d |  |  |
| 26 | 1.4.2.1 | Snesení lávky nad kolejemi č. 2-7 | 1d | 2016-05-02 | 2016-05-02 | 20 | 58d |  | SO 14-26-51 |
| 27 | 1.4.2.2 | Rekonstrukce staniční koleje č.2 včetně prodloužení nástupiště u k.č.2 a obnovy nástupiště mezi k.č.2 a 1. | 30d | 2016-05-02 | 2016-05-31 | 20 | 29d |  | SO 14-10/11-01, SO 14-14-01 |
| 28 | 1.4.2.3 | Dokončení snesení k.č.9, realizace protlaků napříč kolejištěm | 30d | 2016-05-02 | 2016-05-31 | 20 | 29d |  |  |
| 29 | 1.4.2.4 | Přeložky inž. sítí | 57d | 2016-05-02 | 2016-06-27 | 20 | 2d |  |  |
| 30 | 1.4.3 | Rozřezání stávajících konstrukce mostu včetně zapažení | 5d | 2016-06-22 | 2016-06-27 | 33SF | 3d |  | SO 14-20-02 |
| 31 | 1.4.4 | Vložení mostních provizórií do k.č. 1 včetně nutného zapažení | 5d | 2016-06-22 | 2016-06-27 | 33SF | 3d |  | SO 14-20-01 |
| 32 | 1.4.5 | Vložení provizorní výhybky č.X1 do TK směr Rumburk | 3d | 2016-06-24 | 2016-06-27 | 33SF | 3d |  | SO 14-10/11-01 |
| 33 | 1.5 | **Stavební postup č.1** | 69d | 2016-06-27 | 2016-09-03 |  | 268d | 0d |  |
| 34 | 1.5.1 | Provizorní zapojení TK směr Děčín | 1d | 2016-06-27 | 2016-06-27 | 35SS | 317d | 0d | SO 14-10/11-01 |
| 35 | 1.5.2 | Západní část děčínského zhlaví | 69d | 2016-06-27 | 2016-09-03 | 40FF | 298d | 0d | SO 14-10/11-01 |
| 36 | 1.5.3 | Nové mosty na děčínském zhlaví | 50d | 2016-06-27 | 2016-08-15 | 34SS | 317d |  | SO 14-20-02/03 |
| 37 | 1.5.4 | Rekonstrukce koleje mezi výh. st.č.12/21 | 3d | 2016-09-01 | 2016-09-03 | 40FF | 298d |  | SO 14-10/11-01 |
| 38 | 1.6 | Dokončení podchodu včetně technologií | 127d | 2016-06-28 | 2016-11-01 | 19 | 2d | 0d | SO 14-20-01 |
| 39 | 1.7 | ZZ úprava klíčového přístroje | 1d | 2016-06-27 | 2016-06-27 | 34FF | 396d |  |  |
| 40 | 1.8 | **Stavební postup č.2** | 42d | 2016-07-24 | 2016-09-03 |  | 35d | 0d |  |
| 41 | 1.8.1 | Snesení svršku kolejjí č.11,13 | 5d | 2016-07-24 | 2016-07-29 | 44SF | 335d |  | SO 14-10/11-01 |
| 42 | 1.8.2 | Nové koleje č. 5 a 7 | 14d | 2016-08-14 | 2016-08-28 | 46SF | 305d |  | SO 14-10/11-01 |
| 43 | 1.8.3 | Část nových kolejí č.1,3 | 14d | 2016-08-14 | 2016-08-28 | 46SF | 305d |  | SO 14-10/11-01 |
| 44 | 1.8.4 | Výstavba nových nástupišť | 30d | 2016-07-29 | 2016-08-28 | 46SF | 305d | 0d | SO 14-14-01 |
| 45 | 1.8.5 | Vložení provizorní výhybky č. X2 | 1d | 2016-08-27 | 2016-08-28 | 46SF | 305d |  | SO 14-10/11-01 |
| 46 | 1.8.6 | Aktivace zab. zař. na novém kolejišti | 7d | 2016-08-28 | 2016-09-03 | 17 | 0d |  |  |
| 47 | 1.9 | **Stavební postup č.3** | 1d | 2016-09-04 | 2016-09-04 |  | 0d |  |  |
| 48 | 1.9.1 | Odstranění a vložení mostního provizória | 1d | 2016-09-04 | 2016-09-04 | 46 | 0d |  | SO 14-20-01 |
| 49 | 1.9.2 | Propojení TK směr Děčín | 1d | 2016-09-04 | 2016-09-04 | 46 | 0d |  | SO 14-10/11-01 |

| ID | WBS | Task | Duration | Start | Finish | Predecessors | Total slack | Text1 |
| --- | --- | --- | --- | --- | --- | --- | --- | --- |
| 50 | 1.10 | **Stavební postup č.4** | 1d | 2016-09-05 | 2016-09-05 |  | 0d |  |
| 51 | 1.10.1 | Dokončení propojení TK směr Rumburk | 1d | 2016-09-05 | 2016-09-05 | 47 | 0d | SO 14-10/11-01 |
| 52 | 1.11 | **Stavební postup č.5** | 60d | 2016-09-05 | 2016-11-03 |  | 0d |  |
| 53 | 1.11.1 | Nové staniční koleje č. 2,4, 7(položení kolejového roštu) | 60d | 2016-09-05 | 2016-11-03 | 51SS, 38FF | 0d | SO 14-10/11-01 |
| 54 | 1.11.2 | Dokončení děčínského zhlaví | 60d | 2016-09-05 | 2016-11-03 | 51SS, 38FF | 232d | SO 14-10/11-01 |
| 55 | 1.11.3 | Dokončení mostů na děčínském zhlaví | 45d | 2016-09-05 | 2016-10-19 | 53SS | 247d | SO 14-20-02/03 |
| 56 | 1.11.4 | Nové nástupiště u k.č.4 dokončení části nástupiště u k.č.2 | 30d | 2016-10-03 | 2016-11-01 | 38FF | 234d | SO 14-14-01 |
| 57 | 1.12 | **Stavební postup č.6** | 1d | 2016-11-03 | 2016-11-03 |  | 0d |  |
| 58 | 1.12.1 | Propojení TK směr Rumburk | 1d | 2016-11-03 | 2016-11-03 | 53FF | 0d | SO 14-10/11-01 |
| 59 | 1.13 | Aktivace zab. zař. na novém kolejišti | 5d | 2016-11-04 | 2016-11-08 | 52 | 202d |  |
| 60 | 1.14 | **Stavební postup č.7** | 21d | 2016-11-04 | 2016-11-24 |  | 0d |  |
| 61 | 1.14.1 | Dokončení nástupišť a snesení mostních provizórií | 21d | 2016-11-04 | 2016-11-24 | 57 | 186d | SO 14-14-01 |
| 62 | 1.14.2 | Osazení zbývající části přístřešků | 21d | 2016-11-04 | 2016-11-24 | 57 | 186d |  |
| 63 | 1.14.3 | Dokončení železničního svršku a spodku v místě podchodu | 21d | 2016-11-04 | 2016-11-24 | 57 | 0d | SO 14-10/11-01 |
| 64 | 1.14.4 | Výstavba propustků na trati směr Děčín včteně položení železničního svršku | 21d | 2016-11-04 | 2016-11-24 | 57 | 186d | SO 11-20-01 |
| 65 | 1.14.5 | Náhrada výhybky č. X2 kolejovým polem | 1d | 2016-11-04 | 2016-11-04 | 57 | 206d | SO 14-10/11-01 |
| 66 | 1.14.6 | Zasypání podchodu, dokončení nástupišť | 21d | 2016-11-04 | 2016-11-24 | 57 | 186d | SO 14-20-01 |
| 67 | 1.15 | Aktivace zab. zař. na novém kolejišti | 2d | 2016-11-23 | 2016-11-24 | 63FF | 0d |  |
| 68 | 1.16 | Technologická přestávka | 94d | 2016-11-25 | 2017-02-28 | 67 | 0d |  |
| 69 | 1.17 | Přípravné práce | 14d | 2017-03-01 | 2017-03-14 | 68 | 0d |  |
| 70 | 1.18 | **Stavební postup č.8** | 20d | 2017-03-15 | 2017-04-03 |  | 0d |  |
| 71 | 1.18.1 | Zhlaví staničních kolejí č. 11,13,15,17 | 20d | 2017-03-15 | 2017-04-03 | 69 | 0d | SO 14-10/11-01 |
| 72 | 1.19 | Aktivace zab. zař. na novém kolejišti | 2d | 2017-04-04 | 2017-04-05 | 71 | 61d |  |
| 73 | 1.20 | **Stavební postup č.9** | 3d | 2017-04-04 | 2017-04-06 |  | 55d |  |
| 74 | 1.20.1 | Zapojení vlečky na libereckém zhlaví | 3d | 2017-04-04 | 2017-04-06 | 70 | 60d | SO 14-10/11-01 |

| ID | WBS | Task | Duration | Start | Finish | Predecessors | Total slack | Text1 |
| --- | --- | --- | --- | --- | --- | --- | --- | --- |
| 75 | 1.21 | **Stavební postup č.10** | 21d | 2017-04-04 | 2017-04-24 |  | 0d |  |
| 76 | 1.21.1 | Nová TK ve směru na Bakov n/J včetně napojení na zhlaví | 21d | 2017-04-04 | 2017-04-24 | 70 | 0d | SO 14-10/11-01 |
| 77 | 1.21.2 | Nové propustky na trati směr Bakov n/J včetně položení železničního svršku | 21d | 2017-04-04 | 2017-04-24 | 70 | 0d | SO 13-20-01 |
| 78 | 1.22 | Aktivace zab. zař. na novém kolejišti | 3d | 2017-04-25 | 2017-04-27 | 75 | 39d |  |
| 79 | 1.23 | **Stavební postup č.11** | 21d | 2017-04-25 | 2017-05-15 |  | 0d |  |
| 80 | 1.23.1 | Nová TK ve směru na Liberec | 21d | 2017-04-25 | 2017-05-15 | 75 | 0d | SO 14-10/11-01 |
| 81 | 1.23.2 | Nové propustky na trati směr Liberec včetně položení železničního svršku | 21d | 2017-04-25 | 2017-05-15 | 75 | 0d | SO 03-20-01 |
| 82 | 1.23.3 | Nové zapojení lovosického zhlaví | 7d | 2017-04-25 | 2017-05-01 | 75 | 14d | SO 14-10/11-01 |
| 83 | 1.23.4 | Přepojení kabelových tras do nové technologie | 21d | 2017-04-25 | 2017-05-15 | 75 | 0d | SO 02-40-01 |
| 84 | 1.24 | Aktivace zab. zař. na novém kolejišti | 7d | 2017-05-16 | 2017-05-22 | 79 | 0d |  |
| 85 | 1.25 | Dokončovací práce, demolice St.1 | 9d | 2017-05-23 | 2017-05-31 | 84 | 0d |  |
